# basic_one_task_test

Schedule from MS Project, 2019-10-24 to 2020-05-14.

## Calendars

- Standard: Mon-Fri 08:00-12:00, 13:00-17:00; Sat-Sun off.

## Resources

| Resource |
| --- |
| Resource 1 |
| Resource 2 |

## Schedule

| ID | WBS | Task | Type | Duration | Start | Finish | Predecessors | Total slack | Constraint | Resources | Work |
| --- | --- | --- | --- | --- | --- | --- | --- | --- | --- | --- | --- |
| 21 | 1 | **Sign-off** |  | 0d | 2020-05-14 | 2020-05-14 | 20FS+10d | 0d |  |  |  |
| 20 | 1.1 | RC2 | milestone | 0d | 2020-04-30 | 2020-04-30 | 19FS+10d | 0d |  | Resource 1 |  |
| 19 | 1.2 | RC1 | milestone | 0d | 2020-04-16 | 2020-04-16 | 18FS+10d | 0d |  | Resource 1 |  |
| 18 | 1.3 | RC0 | milestone | 0d | 2020-04-02 | 2020-04-02 | 17FS+20d | 0d |  | Resource 1 |  |
| 17 | 1.4 | M4 | milestone | 0d | 2020-03-05 | 2020-03-05 | 16FS+32d | 0d |  | Resource 1 |  |
| 16 | 1.5 | M2 / M3 | milestone | 0d | 2020-01-21 | 2020-01-21 | 15FS+30d | 0d | start no earlier than 2020-01-21 | Resource 1 |  |
| 15 | 1.6 | M1 | milestone | 0d | 2019-11-07 | 2019-11-07 | 13FS+5d | 0d | start no earlier than 2019-11-07 | Resource 1 |  |
| 14 | 2 | Frankfurt (proposed) |  | 135d | 2019-11-07 | 2020-05-14 |  | 0d |  |  |  |
| 13 | 3 | **El Alto Sign-off** |  | 0d | 2019-10-24 | 2019-10-24 |  | 0d | start no earlier than 2019-10-24 | Resource 1 |  |
| 12 | 3.1 | New Year / Golden Week (China) |  | 5d | 2020-01-24 | 2020-01-30 |  | 0d | start no earlier than 2020-01-24 | Resource 2 | 40h |
| 11 | 3.2 | Winter / New Year |  | 10d | 2019-12-23 | 2020-01-03 |  | 0d | start no earlier than 2019-12-23 | Resource 2 | 80h |
| 10 | 3.3 | Thanksgiving (U.S.) |  | 3d | 2019-11-27 | 2019-11-29 |  | 0d | start no earlier than 2019-11-27 | Resource 2 | 24h |
| 9 | 4 | **Holidays** |  | 47d | 2019-11-27 | 2020-01-30 |  | 0d |  |  | 144h |
| 8 | 4.1 | ONS NA |  | 2d | 2020-04-20 | 2020-04-21 |  | 0d | start no earlier than 2020-04-20 | Resource 2 | 16h |
| 7 | 4.2 | Kubecon EU |  | 3d | 2020-03-30 | 2020-04-01 |  | 0d | start no earlier than 2020-03-30 | Resource 2 | 24h |
| 6 | 4.3 | LFN Developer & Testing Forum |  | 4d | 2020-01-13 | 2020-01-16 |  | 0d | start no earlier than 2020-01-13 | Resource 2 | 32h |
| 5 | 4.4 | Windriver Lab Move |  | 5d | 2020-01-06 | 2020-01-10 |  | 0d | start no earlier than 2020-01-06 |  | 40h |
| 4 | 4.5 | Kubecon NA |  | 4d | 2019-11-18 | 2019-11-21 |  | 0d | start no earlier than 2019-11-18 | Resource 2 | 32h |
| 3 | 4.6 | Open Infra Summit |  | 3d | 2019-11-04 | 2019-11-06 |  | 0d | start no earlier than 2019-11-04 | Resource 2 | 24h |
| 2 | 4.7 | Open Source Summit |  | 3d | 2019-10-28 | 2019-10-30 |  | 0d | start no earlier than 2019-10-28 | Resource 2 | 24h |
| 1 | 5 | Events |  | 127d | 2019-10-28 | 2020-04-21 |  | 0d |  |  | 192h |
